# Proyecto1 - Cronograma Montesdeoca

Schedule from MS Project, 2026-07-01 to 2026-08-28.

## Calendars

- Estándar: Mon-Fri 09:00-13:00, 15:00-19:00; Sat-Sun off.

## Resources

| Resource | Unit | Rate |
| --- | --- | --- |
| Aceite quemado | gal | 0.6 |
| Acero de refuerzo fy=4200kg/cm2 | kg | 1.35 |
| Agua en m3 | m3 | 1.05 |
| Alambre galvanizado # 18 | kg | 2.36 |
| alfajias 0.04*0.04*2.40 m | u | 1.5 |
| Arena | m3 | 9.78 |
| Caña Guadua | m. | 0.37 |
| Cemento Portland | kg | 0.17 |
| Clavos 2 1/2" | kg | 1.7 |
| Encofrado para pozos hormigón | m. | 3 |
| Estacas (30 cm) | u | 0.35 |
| lastre | m3 | 5.75 |
| Lubricante | Lt | 1.1 |
| Piedra bola | m3 | 10.35 |
| Pintura anticorrosiva | gal | 18.46 |
| Pintura esmalte | gal | 18.25 |
| Ripio (3/4") - material triturado | m3 | 13.8 |
| Sub base clase 3 | m3 | 3.45 |
| Sumidero H.S. d=600 mm | u | 30 |
| sumidero rectang 600x300mm HD | u | 174.91 |
| Tabla de encofrado 0.30*2.40 m | u | 3.5 |
| tapa redonda HD 600mm | u | 261.33 |
| tiras (2.4x0.025x0.025) - Metros | m. | 0.37 |
| tubería PVC para alcantarillado di=200mm | m. | 11.18 |
| tubería PVC para alcantarillado di=250mm | m. | 13.83 |
| tubería PVC para alcantarillado di=300mm | m. | 20.4 |
| tubería PVC para alcantarillado di=400mm | m. | 35.34 |
| Albañil |  | 4.39 |
| Ayudante de Albañil |  | 4.34 |
| Ayudante de fierrero |  | 4.34 |
| Cadenero |  | 4.39 |
| Chofer profesional de tanquero |  | 6.38 |
| Chofer profesional de volqueta |  | 6.38 |
| Encofrador o carpintero de ribera |  | 4.39 |
| Fierrero |  | 4.39 |
| Maestro mayor en ejecucion de obras civiles |  | 4.87 |
| OPERADOR cargadora frontal |  | 4.87 |
| OPERADOR de tractor de ruedas (barredora, cargadora, rodillo remolcado, franjeadora) |  | 4.64 |
| OPERADOR motoniveladora |  | 4.87 |
| OPERADOR Retroexcavadora |  | 4.87 |
| Peón |  | 4.34 |
| TOPOGRAFO (En Construcción) |  | 4.87 |
| Cargadora Frontal |  | 55 |
| Concretera 1 Saco |  | 6.5 |
| Cortadora de Hierro |  | 3.5 |
| Estación Total |  | 7.5 |
| Herramienta menor |  | 1 |
| Motoniveladora |  | 65 |
| Nivel Laser |  | 1.5 |
| Retroexcavadora (de llanta) |  | 35 |
| Rodillo Vibratorio |  | 45 |
| Tanquero 12m3 |  | 30 |
| Vibrador |  | 3.5 |
| Vibro compactador(de plancha) |  | 4.25 |
| Volqueta 12m3 |  | 35 |
| Transporte |  |  |

## Schedule

| ID | Task | Type | Duration | Start | Finish | Predecessors |
| --- | --- | --- | --- | --- | --- | --- |
| 1 | Replanteo y nivelación para redes hidrosanitarias. | manual | 3d | 2026-07-01 | 2026-07-03 |  |
| 2 | Rasanteo y preparación zanja (inc. Cama de arena). | manual | 15d | 2026-07-08 | 2026-07-28 | 3 |
| 3 | Excavación de suelo natural <2 m (a máquina). | manual | 10d | 2026-07-05 | 2026-07-16 | 1 |
| 4 | Excavación de suelo natural 2 a 4 m (a máquina). | manual | 5d | 2026-07-11 | 2026-07-16 | 3 |
| 5 | Desalojo a máquina (dist= 5 km). | manual | 2d | 2026-07-17 | 2026-07-20 | 4 |
| 6 | Relleno compactado con material lastre. | manual | 8d | 2026-08-07 | 2026-08-18 | 8 |
| 7 | Sub-base clase 3 tendido y compactado (maquina). | manual | 8d | 2026-08-16 | 2026-08-25 | 6 |
| 8 | Relleno compactado (suelo natural). | manual | 7d | 2026-07-29 | 2026-08-06 | 16 |
| 9 | Sum/Ins/Tra Sumidero H.S. d=600 mm salida 200mm. | manual | 6d | 2026-07-24 | 2026-08-03 | 3 |
| 10 | Sum/Ins/Tra Rejilla Sumidero HD 600x300mm. | manual | 6d | 2026-07-28 | 2026-08-05 | 9 |
| 11 | Losa de Tapa HA para pozo revisión e=0.20m d=1.40m. | manual | 5d | 2026-08-19 | 2026-08-25 | 15 |
| 12 | Base H.C. del pozo de revisión d=1.50m e=0.30m. | manual | 3d | 2026-07-28 | 2026-07-31 | 4 |
| 13 | Sum/Ins/Tra Tapa Redonda HD 600mm. | manual | 4d | 2026-08-25 | 2026-08-28 | 11 |
| 14 | Pozo de Revisión H.S f`c=210kg/cm2 h=0-2m di=1m (el cuerpo). | manual | 4d | 2026-07-28 | 2026-08-03 | 12 |
| 15 | Pozo de Revisión H.S f`c=210kg/cm2 h=2-4m di=1m (el cuerpo). | manual | 2d | 2026-07-28 | 2026-07-30 | 12 |
| 16 | Sum/Ins/Tra Tubería PVC para alcantarillado dn=220mm. | manual | 5d | 2026-07-17 | 2026-07-23 | 2 |
| 17 | Sum/Ins/Tra Tubería PVC para alcantarillado dn=280mm. | manual | 3d | 2026-07-23 | 2026-07-27 | 2 |
| 18 | Sum/Ins/Tra Tubería PVC para alcantarillado dn=330mm. | manual | 8d | 2026-07-20 | 2026-07-29 | 2 |
| 19 | Sum/Ins/Tra Tubería PVC para alcantarillado dn=440mm. | manual | 8d | 2026-07-17 | 2026-07-28 | 2 |
| 20 | Hormigón Simple en replantillos f`c=140 kg/cm2. | manual | 2d | 2026-08-01 | 2026-08-03 | 4 |
| 21 | Hormigón simple f`c=210 kg/cm2 con encofrado. | manual | 1d | 2026-08-07 | 2026-08-07 | 22 |
| 22 | Sum/Ins/Tra Acero de Refuerzo fy=4200 kg/cm2. | manual | 3d | 2026-08-04 | 2026-08-06 | 20 |
| 23 | Sum/Ins/Tra Estribos de pozo de revisión d=16mm. | manual | 1d | 2026-07-29 | 2026-07-30 | 15 |
